# Sviluppo software

Schedule from MS Project, 2004-01-01 to 2004-05-13.

## Calendars

- Standard: Mon-Fri 09:00-13:00, 14:00-18:00; Sat-Sun off.

## Resources

| Resource |
| --- |
| Direzione |
| Manager del progetto |
| Analista |
| Sviluppatore |
| Tester |
| Personale addetto alla formazione |
| Redattori di documentazione tecnica |
| Team di sviluppo |

## Schedule

| ID | WBS | Task | Type | Duration | Start | Finish | Predecessors | Total slack | Resources | Work |
| --- | --- | --- | --- | --- | --- | --- | --- | --- | --- | --- |
| 1 | 1 | **Obiettivi globali** |  | 3.5d | 2004-01-01 | 2004-01-06 |  | 0d |  | 28h |
| 2 | 1.1 | Definizione degli obiettivi globali del progetto |  | 4h | 2004-01-01 | 2004-01-01 |  | 0d | Direzione | 4h |
| 3 | 1.2 | Ricerca sponsorizzazione per il progetto |  | 1d | 2004-01-01 | 2004-01-02 | 2 | 0d | Direzione | 8h |
| 4 | 1.3 | Definizione risorse preliminari |  | 1d | 2004-01-02 | 2004-01-05 | 3 | 0d | Manager del progetto | 8h |
| 5 | 1.4 | Definizione risorse di base |  | 1d | 2004-01-05 | 2004-01-06 | 4 | 0d | Manager del progetto | 8h |
| 6 | 1.5 | Obiettivi globali definiti | milestone | 0d | 2004-01-06 | 2004-01-06 | 5 | 0d |  |  |
| 7 | 2 | **Analisi/Requisiti software** |  | 14d | 2004-01-06 | 2004-01-26 |  | 0d |  | 120h |
| 8 | 2.1 | Analisi delle esigenze |  | 5d | 2004-01-06 | 2004-01-13 | 6 | 0d | Analista | 40h |
| 9 | 2.2 | Bozza preliminare delle specifiche software |  | 3d | 2004-01-13 | 2004-01-16 | 8 | 0d | Analista | 24h |
| 10 | 2.3 | Preventivo preliminare |  | 2d | 2004-01-16 | 2004-01-20 | 9 | 0d | Manager del progetto | 16h |
| 11 | 2.4 | Verifica delle specifiche software e del preventivo con il team |  | 4h | 2004-01-20 | 2004-01-20 | 10 | 0d | Manager del progetto; Analista | 8h |
| 12 | 2.5 | Implementazione suggerimenti sulle specifiche del software |  | 1d | 2004-01-21 | 2004-01-21 | 11 | 0d | Analista | 8h |
| 13 | 2.6 | Definizione scadenze di consegna |  | 1d | 2004-01-22 | 2004-01-22 | 12 | 0d | Manager del progetto | 8h |
| 14 | 2.7 | Conseguimento delle autorizzazioni a procedere (per contenuti, scadenze e preventivo) |  | 4h | 2004-01-23 | 2004-01-23 | 13 | 0d | Direzione; Manager del progetto | 8h |
| 15 | 2.8 | Assegnazione risorse necessarie |  | 1d | 2004-01-23 | 2004-01-26 | 14 | 0d | Manager del progetto | 8h |
| 16 | 2.9 | Analisi completata | milestone | 0d | 2004-01-26 | 2004-01-26 | 15 | 0d |  |  |
| 17 | 3 | **Progettazione** |  | 14.5d | 2004-01-26 | 2004-02-13 |  | 0d |  | 120h |
| 18 | 3.1 | Verifica delle specifiche software preliminari |  | 2d | 2004-01-26 | 2004-01-28 | 16 | 0d | Analista | 16h |
| 19 | 3.2 | Sviluppo specifiche funzionali |  | 5d | 2004-01-28 | 2004-02-04 | 18 | 0d | Analista | 40h |
| 20 | 3.3 | Sviluppo del prototipo in base alle specifiche preliminari |  | 4d | 2004-02-04 | 2004-02-10 | 19 | 0d | Analista | 32h |
| 21 | 3.4 | Verifica delle specifiche funzionali |  | 2d | 2004-02-10 | 2004-02-12 | 20 | 0d | Direzione | 16h |
| 22 | 3.5 | Implementazione suggerimenti nelle specifiche funzionali |  | 1d | 2004-02-12 | 2004-02-13 | 21 | 0d | Direzione | 8h |
| 23 | 3.6 | Conseguimento autorizzazione a procedere |  | 4h | 2004-02-13 | 2004-02-13 | 22 | 0d | Direzione; Manager del progetto | 8h |
| 24 | 3.7 | Progettazione completata | milestone | 0d | 2004-02-13 | 2004-02-13 | 23 | 0d |  |  |

| ID | WBS | Task | Type | Duration | Start | Finish | Predecessors | Total slack | Free slack | Resources | Work |
| --- | --- | --- | --- | --- | --- | --- | --- | --- | --- | --- | --- |
| 25 | 4 | **Sviluppo** |  | 21.75d | 2004-02-16 | 2004-03-16 |  | 0d |  |  | 264h |
| 26 | 4.1 | Verifica delle specifiche funzionali |  | 1d | 2004-02-16 | 2004-02-16 | 24 | 0d |  | Sviluppatore | 8h |
| 27 | 4.2 | Identificazione parametri per la progettazione modulare/a più livelli |  | 1d | 2004-02-17 | 2004-02-17 | 26 | 0d |  | Sviluppatore | 8h |
| 28 | 4.3 | Assegnazione membri del team di sviluppo |  | 1d | 2004-02-18 | 2004-02-18 | 27 | 0d |  | Sviluppatore | 8h |
| 29 | 4.4 | Sviluppo del codice |  | 15d | 2004-02-19 | 2004-03-10 | 28 | 0d |  | Sviluppatore | 120h |
| 30 | 4.5 | Testing sviluppatori (debug primario) |  | 15d | 2004-02-24 | 2004-03-16 | 29FS-7.5% | 0d |  | Sviluppatore | 120h |
| 31 | 4.6 | Sviluppo completato | milestone | 0d | 2004-03-16 | 2004-03-16 | 30 | 0d |  |  |  |
| 32 | 5 | **Testing** |  | 48.75d | 2004-02-16 | 2004-04-22 |  | 15d |  |  | 280h |
| 33 | 5.1 | Elaborazione piani di testing dei moduli in base alle specifiche del prodotto |  | 4d | 2004-02-16 | 2004-02-19 | 24 | 17.75d |  | Tester | 32h |
| 34 | 5.2 | Elaborazione piani di testing dei moduli in base alle specifiche del prodotto |  | 4d | 2004-02-16 | 2004-02-19 | 24 | 59.75d |  | Tester | 32h |
| 35 | 5.3 | **Testing dei moduli** |  | 15d | 2004-03-16 | 2004-04-06 |  | 0d |  |  | 120h |
| 36 | 5.3.1 | Controllo del codice modulare |  | 5d | 2004-03-16 | 2004-03-23 | 33, 31 | 0d |  | Tester | 40h |
| 37 | 5.3.2 | Testing dei moduli componenti in base alle specifiche del prodotto |  | 2d | 2004-03-23 | 2004-03-25 | 31, 36 | 0d |  | Tester | 16h |
| 38 | 5.3.3 | Identificazione di anomalie in base alle specifiche del prodotto |  | 3d | 2004-03-25 | 2004-03-30 | 37 | 0d |  | Tester | 24h |
| 39 | 5.3.4 | Modifica del codice |  | 3d | 2004-03-30 | 2004-04-02 | 38 | 0d |  | Tester | 24h |
| 40 | 5.3.5 | Testing del codice modificato |  | 2d | 2004-04-02 | 2004-04-06 | 39 | 0d |  | Tester | 16h |
| 41 | 5.3.6 | Testing dei moduli completato | milestone | 0d | 2004-04-06 | 2004-04-06 | 40 | 0d |  |  |  |
| 42 | 5.4 | **Test di integrazione** |  | 12d | 2004-04-06 | 2004-04-22 |  | 0d |  |  | 96h |
| 43 | 5.4.1 | Test dell'integrazione dei moduli |  | 5d | 2004-04-06 | 2004-04-13 | 41 | 0d |  | Tester | 40h |
| 44 | 5.4.2 | Identificazione di anomalie in base alle specifiche |  | 2d | 2004-04-13 | 2004-04-15 | 43 | 0d |  | Tester | 16h |
| 45 | 5.4.3 | Modifica del codice |  | 3d | 2004-04-15 | 2004-04-20 | 44 | 0d |  | Tester | 24h |
| 46 | 5.4.4 | Testing del codice modificato |  | 2d | 2004-04-20 | 2004-04-22 | 45 | 0d |  | Tester | 16h |
| 47 | 5.4.5 | Test di integrazione completato | milestone | 0d | 2004-04-22 | 2004-04-22 | 46 | 0d |  |  |  |
| 48 | 6 | **Formazione** |  | 45.75d | 2004-02-16 | 2004-04-19 |  | 3d |  |  | 256h |
| 49 | 6.1 | Elaborazione specifiche di formazione per gli utenti finali |  | 3d | 2004-02-16 | 2004-02-18 | 24 | 21.75d | 18.75d | Personale addetto alla formazione | 24h |
| 50 | 6.2 | Elaborazione specifiche di formazione per il personale del supporto tecnico |  | 3d | 2004-02-16 | 2004-02-18 | 24 | 21.75d | 18.75d | Personale addetto alla formazione | 24h |
| 51 | 6.3 | Definizione metodologie di formazione (corsi computerizzati, corsi con istruttore e così via) |  | 2d | 2004-02-16 | 2004-02-17 | 24 | 22.75d | 19.75d | Personale addetto alla formazione | 16h |
| 52 | 6.4 | Preparazione materiale di supporto per la formazione |  | 3w | 2004-03-16 | 2004-04-06 | 49, 31, 50, 51 | 3d | 0d | Personale addetto alla formazione | 120h |
| 53 | 6.5 | Studio di utilizzabilità del materiale di supporto per la formazione |  | 4d | 2004-04-06 | 2004-04-12 | 52 | 3d | 0d | Personale addetto alla formazione | 32h |
| 54 | 6.6 | Completamento materiale di supporto |  | 3d | 2004-04-12 | 2004-04-15 | 53 | 3d | 0d | Personale addetto alla formazione | 24h |
| 55 | 6.7 | Elaborazione sistema di formazione |  | 2d | 2004-04-15 | 2004-04-19 | 54 | 3d | 0d | Personale addetto alla formazione | 16h |
| 56 | 6.8 | Materiale di formazione completato | milestone | 0d | 2004-04-19 | 2004-04-19 | 55 | 3d |  |  |  |

| ID | WBS | Task | Type | Duration | Start | Finish | Predecessors | Total slack | Free slack | Resources | Work |
| --- | --- | --- | --- | --- | --- | --- | --- | --- | --- | --- | --- |
| 57 | 7 | **Documentazione** |  | 30.5d | 2004-02-16 | 2004-03-29 |  | 18.25d |  |  | 336h |
| 58 | 7.1 | Sviluppo specifiche della Guida in linea |  | 1d | 2004-02-16 | 2004-02-16 | 24 | 27.75d | 9.5d | Redattori di documentazione tecnica | 8h |
| 59 | 7.2 | Sviluppo sistema di Guida in linea |  | 3w | 2004-03-01 | 2004-03-22 | 58, 29FS-5% | 18.25d | 0d | Redattori di documentazione tecnica | 120h |
| 60 | 7.3 | Verifica documentazione della Guida in linea |  | 3d | 2004-03-22 | 2004-03-25 | 59 | 18.25d | 0d | Redattori di documentazione tecnica | 24h |
| 61 | 7.4 | Implementazione suggerimenti sulla Guida in linea |  | 2d | 2004-03-25 | 2004-03-29 | 60 | 18.25d | 0d | Redattori di documentazione tecnica | 16h |
| 62 | 7.5 | Definizione specifiche manuali per l'utente |  | 2d | 2004-02-16 | 2004-02-17 | 24 | 27.75d | 8.5d | Redattori di documentazione tecnica | 16h |
| 63 | 7.6 | Stesura manuali per l'utente |  | 3w | 2004-03-01 | 2004-03-22 | 62, 29FS-5% | 19.25d | 0d | Redattori di documentazione tecnica | 120h |
| 64 | 7.7 | Verifica di tutta la documentazione per l'utente |  | 2d | 2004-03-22 | 2004-03-24 | 63 | 19.25d | 0d | Redattori di documentazione tecnica | 16h |
| 65 | 7.8 | Implementazione suggerimenti sulla documentazione per l'utente |  | 2d | 2004-03-24 | 2004-03-26 | 64 | 19.25d | 1d | Redattori di documentazione tecnica | 16h |
| 66 | 7.9 | Documentazione completata | milestone | 0d | 2004-03-29 | 2004-03-29 | 65, 61 | 18.25d |  |  |  |
| 67 | 8 | **Progetto pilota** |  | 70.25d | 2004-01-26 | 2004-05-03 |  | 0d |  |  | 64h |
| 68 | 8.1 | Definizione gruppo per i test |  | 1d | 2004-01-26 | 2004-01-27 | 16 | 61.25d | 0d | Manager del progetto | 8h |
| 69 | 8.2 | Definizione sistema di distribuzione del software |  | 1d | 2004-01-27 | 2004-01-28 | 68 | 61.25d |  |  |  |
| 70 | 8.3 | Installazione/distribuzione del software |  | 1d | 2004-04-22 | 2004-04-23 | 47, 69, 66, 56 | 0d |  | Team di sviluppo | 8h |
| 71 | 8.4 | Raccolta commenti degli utenti |  | 1w | 2004-04-23 | 2004-04-30 | 70 | 0d |  | Team di sviluppo | 40h |
| 72 | 8.5 | Valutazione delle informazioni relative ai test |  | 1d | 2004-04-30 | 2004-05-03 | 71 | 0d |  | Team di sviluppo | 8h |
| 73 | 8.6 | Progetto pilota completato | milestone | 0d | 2004-05-03 | 2004-05-03 | 72 | 0d |  |  |  |
| 74 | 9 | **Installazione** |  | 5d | 2004-05-03 | 2004-05-10 |  | 0d |  |  | 40h |
| 75 | 9.1 | Definizione strategia finale di distribuzione |  | 1d | 2004-05-03 | 2004-05-04 | 73 | 0d |  | Team di sviluppo | 8h |
| 76 | 9.2 | Sviluppo metodologia di distribuzione |  | 1d | 2004-05-04 | 2004-05-05 | 75 | 0d |  | Team di sviluppo | 8h |
| 77 | 9.3 | Assegnazione delle risorse per la distribuzione |  | 1d | 2004-05-05 | 2004-05-06 | 76 | 0d |  | Team di sviluppo | 8h |
| 78 | 9.4 | Formazione personale addetto al supporto tecnico |  | 1d | 2004-05-06 | 2004-05-07 | 77 | 0d |  | Team di sviluppo | 8h |
| 79 | 9.5 | Distribuzione del software |  | 1d | 2004-05-07 | 2004-05-10 | 78 | 0d |  | Team di sviluppo | 8h |
| 80 | 9.6 | Installazione completata | milestone | 0d | 2004-05-10 | 2004-05-10 | 79 | 0d |  |  |  |

| ID | WBS | Task | Type | Duration | Start | Finish | Predecessors | Total slack | Resources | Work |
| --- | --- | --- | --- | --- | --- | --- | --- | --- | --- | --- |
| 81 | 10 | **Verifica post-implementazione** |  | 3d | 2004-05-10 | 2004-05-13 |  | 0d |  | 24h |
| 82 | 10.1 | Analisi di fine progetto (stesura documento) |  | 1d | 2004-05-10 | 2004-05-11 | 80 | 0d | Manager del progetto | 8h |
| 83 | 10.2 | Distribuzione ai membri del team |  | 1d | 2004-05-11 | 2004-05-12 | 82 | 0d | Manager del progetto | 8h |
| 84 | 10.3 | Creazione di un team per la manutenzione del software |  | 1d | 2004-05-12 | 2004-05-13 | 83 | 0d | Manager del progetto | 8h |
| 85 | 10.4 | Verifica post-implementazione completata | milestone | 0d | 2004-05-13 | 2004-05-13 | 84 | 0d |  |  |
| 86 | 11 | Modello di sviluppo software completato | milestone | 0d | 2004-05-13 | 2004-05-13 | 85 | 0d |  |  |
